# PAQUETE 6 - CHICAMA

Schedule from Primavera P6, 2024-06-19 to 2025-12-15, data date 2024-06-19.
Must finish by 2025-12-16

## Calendars

- 2T 7x0 -10 h: Mon-Sun 08:00-18:00.

## Resources

| Resource | Group | Unit |
| --- | --- | --- |
| Cemento Portlamd Tipo I (42.5 kg) | material |  |
| Geotextil no tejido 400 gr/m2 | material |  |
| Geotextil no tejido 200 gr/m2 | material |  |
| Roca | material | m3 |
| Concreto premezclado F'C=100 kg/cm2 | material |  |
| Acero Corrugado fy = 4200 kg/cm2 grado 60 | material |  |
| Concreto premezclado F'C=280 kg/cm2 | material |  |
| Concreto premezclado F'C=175 kg/cm2 | material |  |
| Roca con mortero | material | m3 |
| GAVION COLCHON PLASTIFICADO 5x2x0.3 m, abertura 10x12 cm, 3.7mm | material |  |
| GAVION TIPO CAJA DE 5.0 x 1.0 x 1.0 m, abertura 10x12cm, Dext=3,7mm (PVC) | material |  |
| GAVION TIPO CAJA DE 5.0 x 1.0 x 0.5 m, abertura 10x12cm, Dext=3,7mm (PVC) | material |  |
| Geocompuesto de Drenaje | material |  |
| arena gruesa | material |  |
| REJILLA METALICA 2.20x1.50m | material |  |
| Mamposteria piedra | material | m3 |

## Schedule

| ID | WBS | Activity | Type | Duration | Start | Finish | Predecessors | Total float | Free float | Resources |
| --- | --- | --- | --- | --- | --- | --- | --- | --- | --- | --- |
|  | 9 | **HITOS** |  |  | 2024-06-19 | 2025-12-15 |  |  |  |  |
| A1210 |  | Inicio | milestone | 0d | 2024-06-19 | 2024-06-19 |  | 0d |  |  |
| A1220 |  | Fin | milestone | 0d | 2025-12-15 | 2025-12-15 | A1003 FF, A1005 FF, A1006 FF, A1027 FF, A1008 FF, A1002 FF, A1270 FF, A1390 FF, A1290 FF, A1370 FF, A1250 FF, A1430 FF, A1410 FF, A1470 FF | 0d |  |  |
|  | 1 | **OBRAS PRELIMINARES** |  |  | 2024-06-19 | 2025-12-15 |  |  |  |  |
| A1001 |  | Trazo y replanteo topográfico al inicio de obra |  | 15d | 2024-06-19 | 2024-07-03 | A1210 SS | 7d | 0d | Cemento Portlamd Tipo I (42.5 kg) [1.5] |
| A1004 |  | Cartel de Obra de 7.00 x 3.50 m |  | 1d | 2024-06-19 | 2024-06-19 | A1210 SS | 7d | 0d |  |
| A1007 |  | Movilización de equipos a obra |  | 7d | 2024-06-19 | 2024-06-25 | A1210 SS | 0d |  |  |
| A1006 |  | Señalización de obra |  | 532d | 2024-06-25 | 2025-12-08 | A1004 FS+5d | 7d |  |  |
| A1005 |  | Mantenimiento de accesos (L<15 km) |  | 526d | 2024-07-01 | 2025-12-08 | A1210 SS, A1007 SS+12d | 7d |  |  |
| A1002 |  | Trazo y replanteo topográfico durante la ejecución de obra |  | 523d | 2024-07-04 | 2025-12-08 | A1001 | 7d |  | Cemento Portlamd Tipo I (42.5 kg) [52] |
| A1003 |  | Levantamiento topografico final de obra |  | 15d | 2025-11-24 | 2025-12-08 | A1177 SS+14d | 7d |  | Cemento Portlamd Tipo I (42.5 kg) [2] |
| A1008 |  | Desmovilización de equipos a obra |  | 7d | 2025-12-09 | 2025-12-15 | A1033, A1195, A1177, A1203, A1078 | 0d |  |  |
|  | 4 | **Construcción de campamentos (talleres, almacenes y oficinas)** |  |  | 2024-07-01 | 2025-12-08 |  |  |  |  |
| A1028 |  | Desbroce y remoción de suelo vegetal con equipo |  | 4d | 2024-07-01 | 2024-07-04 | A1007 FS+5d | 7d | 0d |  |
| A1025 |  | Conformación de terraplén para campamentos |  | 22d | 2024-07-05 | 2024-07-26 | A1028 | 7d | 0d |  |
| A1026 |  | Construcción de campamentos |  | 25d | 2024-07-08 | 2024-08-01 | A1025 SS+3d | 7d | 0d |  |
| A1027 |  | Mantenimiento de campamentos |  | 514d | 2024-07-13 | 2025-12-08 | A1026 SS+5d | 7d |  |  |
|  | 5 | **Acondicionamiento de terrenos para DME y DMO** |  |  | 2024-07-01 | 2025-12-07 |  |  |  |  |
| A1032 |  | Desbroce y remoción de suelo vegetal con equipo |  | 14d | 2024-07-01 | 2024-07-14 | A1007 FS+5d | 1d | 0d |  |
| A1030 |  | Acondicionamiento de terrenos para DME y DMO |  | 201d | 2024-07-04 | 2025-01-20 | A1032 SS+3d | 1d | 0d |  |
| A1031 |  | Conformación de material excedente en DME y DMO |  | 508d | 2024-07-09 | 2025-11-28 | A1030 SS+5d | 1d | 0d |  |
| A1033 |  | Restauración y revegetación de áreas intervenidas |  | 9d | 2025-11-29 | 2025-12-07 | A1031 | 1d |  |  |
|  | 2 | **Rehabilitación de accesos existentes** |  |  | 2024-07-04 | 2025-05-22 |  |  |  |  |
| A1017 |  | Rehabilitación de accesos existentes |  | 15d | 2024-07-04 | 2024-07-18 | A1007 FS+8d | 0d |  |  |
| A1108 |  | Sector 1 - Suministro, transporte e instalación de alcantarillas HDPE corrugada con baden |  | 14d | 2024-07-19 | 2024-08-01 | A1017, A1280 SS | 325d | 136d |  |
| A1208 |  | Sector 3 - Suministro, transporte e instalación de alcantarillas HDPE corrugada con baden |  | 8d | 2024-12-16 | 2024-12-23 | A1300 SS, A1108 | 199d | 136d |  |
| A1158 |  | Sector 2 - Suministro, transporte e instalación de alcantarillas HDPE corrugada con baden |  | 18d | 2025-02-04 | 2025-02-21 | A1108, A1260 SS | 139d | 76d |  |
| A1218 |  | Sector 4 - Suministro, transporte e instalación de alcantarillas HDPE corrugada con baden |  | 14d | 2025-05-09 | 2025-05-22 | A1208, A1320 SS, A1158 | 63d | 3d |  |

| ID | WBS | Activity | Type | Duration | Start | Finish | Predecessors | Total float | Free float | Resources |
| --- | --- | --- | --- | --- | --- | --- | --- | --- | --- | --- |
|  | 1 | **Construcción de acceso nuevo** |  |  | 2024-07-06 | 2024-08-04 |  |  |  |  |
| A1014 |  | Desbroce y remoción de suelo vegetal con equipo |  | 4d | 2024-07-06 | 2024-07-09 | A1007 FS+10d | 47d | 0d |  |
| A1011 |  | Excavación en material común para accesos |  | 20d | 2024-07-10 | 2024-07-29 | A1014 | 47d | 0d |  |
| A1013 |  | Proceso y selección de material propio |  | 7d | 2024-07-10 | 2024-07-16 | A1011 SS | 47d | 0d |  |
| A1012 |  | Relleno compactado con equipo pesado para accesos |  | 13d | 2024-07-17 | 2024-07-29 | A1013 | 47d | 0d |  |
| A1015 |  | Habilitación de acceso temporal en cauce de río (Inc. Instalación y Retiro de alcantarilla) |  | 19d | 2024-07-17 | 2024-08-04 | A1013 | 47d | 0d |  |
|  | 3 | **Conformación de ataguía para desvío temporal de cauce de río** |  |  | 2024-07-01 | 2025-11-19 |  |  |  |  |
| A1022 |  | Conformación de ataguía para desvío temporal de cauce de río |  | 507d | 2024-07-01 | 2025-11-19 | A1007 FS+5d | 26d | 6d |  |
| A1023 |  | Colocación de roca al volteo |  | 325d | 2024-07-17 | 2025-06-06 | A1022 SS+10d, A1012 SS, A1015 SS | 47d |  |  |
|  | 13 | **ENCAUZAMIENTO DE RÍO** |  |  | 2024-07-19 | 2025-12-08 |  |  |  |  |
|  | 2 | **ENCAUZAMIENTO DE RÍO - SECTOR 1** |  |  | 2024-07-19 | 2025-04-30 |  |  |  |  |
| A1280 |  | Inicio Sector 1 | milestone | 0d | 2024-07-19 | 2024-07-19 | A1007, A1017 | 0d |  |  |
| A1290 |  | Fin Sector 1 | milestone | 0d | 2025-04-30 | 2025-04-30 | A1064, A1420 FF, A1240 FF, A1400 FF | 229d |  |  |
|  | 1 | **MOVIMIENTO DE TIERRAS PARA DIQUE LONGITUDINALES - SECTOR 1** |  |  | 2024-07-19 | 2025-03-28 |  |  |  |  |
| A1036 |  | Desbroce y remoción de suelo vegetal con equipo |  | 9d | 2024-07-19 | 2024-07-27 | A1280 | 0d |  |  |
| A1037 |  | Excavación en material común |  | 84d | 2024-07-28 | 2024-10-19 | A1036 | 0d |  |  |
| A1040 |  | Conformación y compactación de superficie para fundación con equipo pesado |  | 49d | 2024-08-07 | 2024-09-24 | A1041 SS | 283d | 89d |  |
| A1041 |  | Relleno compactado con equipo pesado |  | 138d | 2024-08-07 | 2024-12-22 | A1037 SS+10d | 25d | 0d |  |
| A1046 |  | Proceso y selección de material propio |  | 114d | 2024-08-07 | 2024-11-28 | A1037 SS+10d | 248d | 118d |  |
| A1038 |  | Excavación para conformación de uña antisocavante |  | 126d | 2024-08-12 | 2024-12-15 | A1037 SS+15d | 0d |  |  |
| A1043 |  | Perfilado de taludes de dique con equipo |  | 90d | 2024-08-12 | 2024-11-09 | A1041 SS+5d | 25d | 0d |  |
| A1044 |  | Suministro, habilitación y colocación de geotextil no tejido 400 g/m2 |  | 70d | 2024-08-17 | 2024-10-25 | A1043 SS+5d | 25d | 0d | Geotextil no tejido 400 gr/m2 [90006.4]; Geotextil no tejido 200 gr/m2 [1020] |
| A1039 |  | Colocación de protección para geotextil |  | 118d | 2024-08-22 | 2024-12-17 | A1044 SS+5d | 25d | 0d |  |
| A1042 |  | Relleno propio sin compactar |  | 30d | 2024-12-23 | 2025-01-21 | A1041, A1040 | 194d | 64d |  |
| A1045 |  | Suministro, habilitación y colocación de geotextil no tejido 200 g/m2 |  | 2d | 2025-03-27 | 2025-03-28 | A1042, A1046, A1059 SS | 130d | 10d |  |

| ID | WBS | Activity | Type | Duration | Start | Finish | Predecessors | Total float | Free float | Resources |
| --- | --- | --- | --- | --- | --- | --- | --- | --- | --- | --- |
|  | 2 | **ENROCADO DE PROTECCIÓN - SECTOR 1** |  |  | 2024-09-11 | 2025-04-07 |  |  |  |  |
| A1049 |  | Colocación de roca seleccionada, en uña antisocavante |  | 202d | 2024-09-11 | 2025-03-31 | A1039 SS+20d | 25d | 0d | Roca [92130.9 m3] |
| A1048 |  | Colocación de roca seleccionada, en cara húmeda de talud |  | 179d | 2024-10-11 | 2025-04-07 | A1039 SS+10d, A1049 SS+30d | 28d | 3d | Roca [69733.4 m3] |
|  | 3 | **REMOCION DE ENROCADO DE DIQUES EN MAL ESTADO - SECTOR 1** |  |  | 2024-10-20 | 2025-02-18 |  |  |  |  |
| A1051 |  | Remoción de enrocado de cara húmeda de talud |  | 86d | 2024-10-20 | 2025-01-13 | A1037 | 33d | 0d |  |
| A1052 |  | Selección y acopio de roca removida |  | 36d | 2025-01-14 | 2025-02-18 | A1051 | 33d | 0d |  |
|  | 4 | **CONCRETO ARMADO - SECTOR 1** |  |  | 2025-01-29 | 2025-04-05 |  |  |  |  |
| A1054 |  | Suministro y colocación de concreto premezclado f´c=100 kg/cm2, e=0.10 m para solado |  | 53d | 2025-01-29 | 2025-03-22 | A1049 SS+140d | 120d | 0d | Concreto premezclado F'C=100 kg/cm2 [128] |
| A1056 |  | Suministro, habilitación y colocación de acero de refuerzo f'y=4200 kg/cm2 |  | 57d | 2025-01-29 | 2025-03-26 | A1054 SS | 120d | 0d | Acero Corrugado fy = 4200 kg/cm2 grado 60 [118999] |
| A1055 |  | Suministro, habilitación, encofrado y desencofrado para estructuras |  | 56d | 2025-02-03 | 2025-03-30 | A1054 SS+5d | 143d | 0d |  |
| A1057 |  | Suministro y colocación de concreto estructural premezclado f´c=280 kg/cm2 |  | 42d | 2025-02-18 | 2025-03-31 | A1055 SS+15d, A1056 SS+15d | 143d | 0d | Concreto premezclado F'C=280 kg/cm2 [1340] |
| A1058 |  | Suministro y colocación de enrocado con mortero (70% enrocado+ 30% mortero f´c=175 kg/cm2) |  | 32d | 2025-03-05 | 2025-04-05 | A1057 SS+15d | 143d | 23d | Concreto premezclado F'C=175 kg/cm2 [860]; Roca con mortero [1780 m3] |
| A1059 |  | Junta de Dilatación para muros de Poliestireno Expandido e=1" |  | 7d | 2025-03-27 | 2025-04-02 | A1056 | 120d | 0d |  |
|  | 5 | **GAVIONES - SECTOR 1** |  |  | 2025-04-03 | 2025-04-30 |  |  |  |  |
| A1061 |  | Suministro y colocación de colchón caja plastificada de 5.0x2.0x0.30 m (Malla 10x12 cm. Dext=3.7mm) |  | 5d | 2025-04-03 | 2025-04-07 | A1059 | 120d | 0d | GAVION COLCHON PLASTIFICADO 5x2x0.3 m, abertura 10x12 cm, 3.7mm [47] |
| A1062 |  | Suministro y colocación gavión caja plastificada de 5.0x1.0x1.5 m (Malla 10x12 cm. Dext=3.7mm) |  | 4d | 2025-04-08 | 2025-04-11 | A1061, A1045 | 120d | 0d | GAVION TIPO CAJA DE 5.0 x 1.0 x 1.0 m, abertura 10x12cm, Dext=3,7mm (PVC) [24] |
| A1063 |  | Suministro y colocación gavión caja plastificada de 5.0x1.0x1.0 m (Malla 10x12 cm. Dext=3.7mm) |  | 17d | 2025-04-12 | 2025-04-28 | A1062 | 120d | 0d | GAVION TIPO CAJA DE 5.0 x 1.0 x 1.0 m, abertura 10x12cm, Dext=3,7mm (PVC) [137] |
| A1064 |  | Suministro y colocación gavión caja plastificada de 5.0x1.0x0.5 m (Malla 10x12 cm. Dext=3.7mm) |  | 2d | 2025-04-29 | 2025-04-30 | A1063, A1058 | 120d | 0d | GAVION TIPO CAJA DE 5.0 x 1.0 x 0.5 m, abertura 10x12cm, Dext=3,7mm (PVC) [24] |
|  | 3 | **ENCAUZAMIENTO DE RÍO - SECTOR 2** |  |  | 2025-02-04 | 2025-11-13 |  |  |  |  |
| A1260 |  | Inicio Sector 2 | milestone | 0d | 2025-02-04 | 2025-02-04 | A1007, A1017 FS+200d | 34d | 0d |  |
| A1270 |  | Fin Sector 2 | milestone | 0d | 2025-11-13 | 2025-11-13 | A1078, A1083 FF, A1085 FF, A1076 FF, A1073 FF | 32d |  |  |
|  | 1 | **MOVIMIENTO DE TIERRAS PARA DIQUE LONGITUDINALES - SECTOR 2** |  |  | 2025-02-04 | 2025-11-04 |  |  |  |  |
| A1067 |  | Desbroce y remoción de suelo vegetal con equipo |  | 9d | 2025-02-04 | 2025-02-12 | A1260 | 34d | 0d |  |
| A1068 |  | Excavación en material común |  | 140d | 2025-02-13 | 2025-07-02 | A1067 | 34d | 0d |  |
| A1076 |  | Proceso y selección de material propio |  | 201d | 2025-02-18 | 2025-09-06 | A1068 SS+5d | 100d | 68d |  |
| A1069 |  | Excavación para conformación de uña antisocavante |  | 134d | 2025-02-19 | 2025-07-02 | A1068 SS+5d, A1052 | 33d | 0d |  |
| A1071 |  | Conformación y compactación de superficie para fundación con equipo pesado |  | 63d | 2025-02-24 | 2025-04-27 | A1069 SS+5d | 36d | 3d |  |
| A1072 |  | Relleno compactado con equipo pesado |  | 193d | 2025-03-01 | 2025-09-09 | A1069 SS+10d, A1071 SS+2d | 33d | 0d |  |
| A1074 |  | Perfilado de taludes de dique con equipo |  | 108d | 2025-03-11 | 2025-06-26 | A1072 SS+10d | 33d | 0d |  |
| A1075 |  | Suministro, habilitación y colocación de geotextil no tejido 400 g/m2 |  | 90d | 2025-03-21 | 2025-06-18 | A1074 SS+10d | 33d | 0d | Geotextil no tejido 400 gr/m2 [112609] |
| A1070 |  | Colocación de protección para geotextil |  | 150d | 2025-03-26 | 2025-08-22 | A1075 SS+5d | 33d | 8d |  |
| A1073 |  | Relleno propio sin compactar |  | 56d | 2025-09-10 | 2025-11-04 | A1072, A1042 | 41d | 0d |  |

| ID | WBS | Activity | Type | Duration | Start | Finish | Predecessors | Total float | Free float | Resources |
| --- | --- | --- | --- | --- | --- | --- | --- | --- | --- | --- |
|  | 2 | **ENROCADO DE PROTECCIÓN - SECTOR 2** |  |  | 2025-04-06 | 2025-11-13 |  |  |  |  |
| A1079 |  | Colocación de roca seleccionada, en uña antisocavante |  | 215d | 2025-04-06 | 2025-11-06 | A1070 SS+3d, A1049 FS+5d | 25d | 0d | Roca [97688.8 m3] |
| A1078 |  | Colocación de roca seleccionada, en cara húmeda de talud |  | 217d | 2025-04-11 | 2025-11-13 | A1079 SS+5d, A1048 | 25d | 0d | Roca [112769 m3] |
|  | 3 | **REMOCION DE ENROCADO DE DIQUES EN MAL ESTADO - SECTOR 2** |  |  | 2025-05-24 | 2025-10-19 |  |  |  |  |
| A1081 |  | Remoción de enrocado de cara húmeda de talud |  | 83d | 2025-05-24 | 2025-08-14 | A1068 SS+100d | 57d | 0d |  |
| A1082 |  | Remoción de enrocado de uña |  | 20d | 2025-08-15 | 2025-09-03 | A1081 | 57d | 0d |  |
| A1083 |  | Selección y acopio de roca removida |  | 46d | 2025-09-04 | 2025-10-19 | A1082, A1052 | 57d | 25d |  |
|  | 5 | **GAVIONES - SECTOR 2** |  |  | 2025-07-15 | 2025-10-31 |  |  |  |  |
| A1085 |  | Suministro y colocación gavión caja plastificada de 5.0x1.0x1.0 m (Malla 10x12 cm. Dext=3.7mm) |  | 109d | 2025-07-15 | 2025-10-31 | A1079 SS+100d, A1064 | 45d | 13d | GAVION TIPO CAJA DE 5.0 x 1.0 x 1.0 m, abertura 10x12cm, Dext=3,7mm (PVC) [444] |
|  | 4 | **ENCAUZAMIENTO DE RÍO - SECTOR 3** |  |  | 2024-12-16 | 2025-05-08 |  |  |  |  |
| A1300 |  | Inicio Sector 3 | milestone | 0d | 2024-12-16 | 2024-12-16 | A1038 | 0d |  |  |
| A1310 |  | Fin Sector 3 | milestone | 0d | 2025-05-08 | 2025-05-08 | A1102, A1088 FF, A1440 FF, A1490 FF | 0d |  |  |
|  | 1 | **DESCOLMATACIÓN DE CAUCE DE RÍO - SECTOR 3** |  |  | 2024-12-20 | 2025-03-29 |  |  |  |  |
| A1088 |  | Excavación en material común saturado |  | 100d | 2024-12-20 | 2025-03-29 | A1090 | 40d |  |  |
|  | 2 | **MOVIMIENTO DE TIERRAS PARA DIQUE LONGITUDINALES - SECTOR 3** |  |  | 2024-12-16 | 2025-04-12 |  |  |  |  |
| A1090 |  | Desbroce y remoción de suelo vegetal con equipo |  | 4d | 2024-12-16 | 2024-12-19 | A1300 | 0d |  |  |
| A1091 |  | Excavación en material común |  | 25d | 2024-12-20 | 2025-01-13 | A1090 | 0d |  |  |
| A1094 |  | Conformación y compactación de superficie para fundación con equipo pesado |  | 16d | 2024-12-25 | 2025-01-09 | A1091 SS+5d | 2d |  |  |
| A1100 |  | Proceso y selección de material propio |  | 76d | 2024-12-25 | 2025-03-10 | A1091 SS+5d | 0d |  |  |
| A1095 |  | Relleno compactado con equipo pesado |  | 76d | 2024-12-30 | 2025-03-15 | A1100 SS+5d, A1091 SS+5d, A1094 SS+3d | 0d |  |  |
| A1097 |  | Perfilado de taludes de dique con equipo |  | 24d | 2025-01-04 | 2025-01-27 | A1095 SS+5d | 0d |  |  |
| A1098 |  | Suministro, habilitación y colocación de geotextil no tejido 400 g/m2 |  | 25d | 2025-01-06 | 2025-01-30 | A1095 SS+3d, A1097 SS+2d | 0d |  | Geotextil no tejido 400 gr/m2 [27485.7]; Geotextil no tejido 200 gr/m2 [2252.68] |
| A1093 |  | Colocación de protección para geotextil |  | 35d | 2025-01-11 | 2025-02-14 | A1098 SS+5d | 0d |  |  |
| A1092 |  | Excavación para conformación de uña antisocavante |  | 15d | 2025-01-14 | 2025-01-28 | A1091 | 106d | 0d |  |
| A1099 |  | Suministro, habilitación y colocación de geotextil no tejido 200 g/m2 |  | 4d | 2025-01-29 | 2025-02-01 | A1092 | 106d | 7d |  |
| A1096 |  | Relleno propio sin compactar |  | 28d | 2025-03-16 | 2025-04-12 | A1095 | 225d | 48d |  |

| ID | WBS | Activity | Type | Duration | Start | Finish | Predecessors | Total float | Free float | Resources |
| --- | --- | --- | --- | --- | --- | --- | --- | --- | --- | --- |
|  | 3 | **ENROCADO DE PROTECCIÓN - SECTOR 3** |  |  | 2025-01-13 | 2025-05-08 |  |  |  |  |
| A1103 |  | Colocación de roca seleccionada, en uña antisocavante |  | 80d | 2025-01-13 | 2025-04-02 | A1093 SS+2d | 0d |  | Roca [21204.7 m3] |
| A1102 |  | Colocación de roca seleccionada, en cara húmeda de talud |  | 91d | 2025-02-07 | 2025-05-08 | A1103 SS+25d | 0d |  | Roca [23562.1 m3] |
|  | 4 | **REMOCION DE ENROCADO DE DIQUES EN MAL ESTADO - SECTOR 3** |  |  | 2025-01-29 | 2025-02-13 |  |  |  |  |
| A1105 |  | Remoción de enrocado de cara húmeda de talud |  | 9d | 2025-01-29 | 2025-02-06 | A1092 | 139d | 0d |  |
| A1106 |  | Remoción de enrocado de uña |  | 2d | 2025-02-07 | 2025-02-08 | A1105 | 139d | 0d |  |
| A1107 |  | Selección y acopio de roca removida |  | 5d | 2025-02-09 | 2025-02-13 | A1106 | 139d | 137d |  |
|  | 5 | **CONCRETO ARMADO - SECTOR 3** |  |  | 2025-01-04 | 2025-04-14 |  |  |  |  |
| A1109 |  | Suministro y colocación de concreto premezclado f´c=100 kg/cm2, e=0.10 m para solado |  | 60d | 2025-01-04 | 2025-03-04 | A1091 SS+15d | 72d | 0d | Concreto premezclado F'C=100 kg/cm2 [145] |
| A1111 |  | Suministro, habilitación y colocación de acero de refuerzo f'y=4200 kg/cm2 |  | 60d | 2025-01-04 | 2025-03-04 | A1109 SS | 91d | 85d | Acero Corrugado fy = 4200 kg/cm2 grado 60 [154888] |
| A1118 |  | Entibados para prevención del desprendimiento de tierras |  | 10d | 2025-01-04 | 2025-01-13 | A1109 SS | 141d | 135d |  |
| A1110 |  | Suministro, habilitación, encofrado y desencofrado para estructuras |  | 57d | 2025-01-14 | 2025-03-11 | A1109 SS+10d | 72d | 0d |  |
| A1112 |  | Suministro y colocación de concreto estructural premezclado f´c=280 kg/cm2 |  | 50d | 2025-01-19 | 2025-03-09 | A1110 SS+5d | 72d | 0d | Concreto premezclado F'C=280 kg/cm2 [1340]; Concreto premezclado F'C=280 kg/cm2 [1599] |
| A1114 |  | Suministro, habilitación y colocación de geocompuesto de drenaje |  | 68d | 2025-02-03 | 2025-04-11 | A1112 SS+15d | 120d | 0d | Geocompuesto de Drenaje [3281] |
| A1113 |  | Suministro y colocación de enrocado con mortero (70% enrocado+ 30% mortero f´c=175 kg/cm2) |  | 44d | 2025-02-08 | 2025-03-23 | A1112 SS+20d | 72d | 66d | Concreto premezclado F'C=175 kg/cm2 [1168]; Roca con mortero [2497 m3] |
| A1117 |  | Junta de Dilatación para muros de Poliestireno Expandido e=1" |  | 7d | 2025-03-10 | 2025-03-16 | A1112 | 79d | 73d |  |
| A1115 |  | Suministro, habilitación e instalación de Tubería PVC Ø=2" |  | 2d | 2025-03-12 | 2025-03-13 | A1110 | 149d | 29d |  |
| A1116 |  | Suministro, habilitación e instalación de Tubería HDPE corrugada Ø=4" |  | 3d | 2025-04-12 | 2025-04-14 | A1114, A1115 | 120d | 115d | arena gruesa [61.53] |
|  | 6 | **GAVIONES - SECTOR 3** |  |  | 2025-01-24 | 2025-04-04 |  |  |  |  |
| A1120 |  | Suministro y colocación de colchón caja plastificada de 5.0x2.0x0.30 m (Malla 10x12 cm. Dext=3.7mm) |  | 4d | 2025-01-24 | 2025-01-27 | A1109 SS+20d | 99d | 0d | GAVION COLCHON PLASTIFICADO 5x2x0.3 m, abertura 10x12 cm, 3.7mm [31] |
| A1121 |  | Suministro y colocación gavión caja plastificada de 5.0x1.5x0.5 m (Malla 10x12 cm. Dext=3.7mm) |  | 5d | 2025-01-28 | 2025-02-01 | A1120 | 99d | 0d | GAVION TIPO CAJA DE 5.0 x 1.0 x 0.5 m, abertura 10x12cm, Dext=3,7mm (PVC) [45] |
| A1122 |  | Suministro y colocación gavión caja plastificada de 5.0x1.0x1.5 m (Malla 10x12 cm. Dext=3.7mm) |  | 7d | 2025-02-02 | 2025-02-08 | A1121 | 99d | 0d | GAVION TIPO CAJA DE 5.0 x 1.0 x 0.5 m, abertura 10x12cm, Dext=3,7mm (PVC) [45] |
| A1123 |  | Suministro y colocación gavión caja plastificada de 5.0x1.0x1.0 m (Malla 10x12 cm. Dext=3.7mm) |  | 55d | 2025-02-09 | 2025-04-04 | A1122, A1099 | 99d | 39d | GAVION TIPO CAJA DE 5.0 x 1.0 x 0.5 m, abertura 10x12cm, Dext=3,7mm (PVC) [446] |
|  | 5 | **ENCAUZAMIENTO DE RÍO - SECTOR 4** |  |  | 2025-05-09 | 2025-07-26 |  |  |  |  |
| A1320 |  | Inicio Sector 4 | milestone | 0d | 2025-05-09 | 2025-05-09 | A1102, A1310 | 0d |  |  |
| A1330 |  | Fin Sector 4 | milestone | 0d | 2025-07-23 | 2025-07-23 | A1137 FF, A1450 FF, A1500 FF, A1142 FF | 0d |  |  |

| ID | WBS | Activity | Type | Duration | Start | Finish | Predecessors | Total float | Free float | Resources |
| --- | --- | --- | --- | --- | --- | --- | --- | --- | --- | --- |
|  | 1 | **MOVIMIENTO DE TIERRAS PARA DIQUE LONGITUDINALES - SECTOR 4** |  |  | 2025-05-09 | 2025-06-09 |  |  |  |  |
| A1126 |  | Excavación en material común |  | 8d | 2025-05-09 | 2025-05-16 | A1320 SS | 0d |  |  |
| A1135 |  | Proceso y selección de material propio |  | 10d | 2025-05-12 | 2025-05-21 | A1126 SS+3d | 2d | 0d |  |
| A1129 |  | Conformación y compactación de superficie para fundación con equipo pesado |  | 12d | 2025-05-16 | 2025-05-27 | A1126 SS+7d | 22d | 0d |  |
| A1127 |  | Excavación para conformación de uña antisocavante |  | 11d | 2025-05-17 | 2025-05-27 | A1126 | 0d |  |  |
| A1130 |  | Relleno compactado con equipo pesado |  | 12d | 2025-05-19 | 2025-05-30 | A1129 SS+3d | 22d | 0d |  |
| A1132 |  | Perfilado de taludes de dique con equipo |  | 14d | 2025-05-20 | 2025-06-02 | A1130 SS+1d | 22d | 0d |  |
| A1133 |  | Suministro, habilitación y colocación de geotextil no tejido 400 g/m2 |  | 12d | 2025-05-20 | 2025-05-31 | A1132 SS | 22d | 0d | Geotextil no tejido 400 gr/m2 [18239]; Geotextil no tejido 200 gr/m2 [1471] |
| A1128 |  | Colocación de protección para geotextil |  | 20d | 2025-05-21 | 2025-06-09 | A1133 SS+1d | 22d | 0d |  |
| A1134 |  | Suministro, habilitación y colocación de geotextil no tejido 200 g/m2 |  | 3d | 2025-05-26 | 2025-05-28 | A1144, A1218 | 60d |  |  |
| A1131 |  | Relleno propio sin compactar |  | 4d | 2025-05-31 | 2025-06-03 | A1130, A1096 | 177d | 98d |  |
|  | 2 | **ENROCADO DE PROTECCIÓN - SECTOR 4** |  |  | 2025-05-21 | 2025-07-23 |  |  |  |  |
| A1138 |  | Colocación de roca seleccionada, en uña antisocavante |  | 46d | 2025-05-21 | 2025-07-05 | A1128 SS, A1126 SS | 22d |  | Roca [12547 m3] |
| A1137 |  | Colocación de roca seleccionada, en cara húmeda de talud |  | 42d | 2025-06-12 | 2025-07-23 | A1127 FS+15d, A1138 SS | 0d |  | Roca [10773 m3] |
|  | 3 | **REMOCION DE ENROCADO DE DIQUES EN MAL ESTADO - SECTOR 4** |  |  | 2025-05-15 | 2025-07-21 |  |  |  |  |
| A1140 |  | Remoción de enrocado de cara húmeda de talud |  | 42d | 2025-05-15 | 2025-06-25 | A1135 SS+3d | 2d | 0d |  |
| A1141 |  | Remoción de enrocado de uña |  | 5d | 2025-06-26 | 2025-06-30 | A1140 | 2d | 0d |  |
| A1142 |  | Selección y acopio de roca removida |  | 21d | 2025-07-01 | 2025-07-21 | A1141, A1107 | 2d |  |  |
|  | 5 | **GAVIONES - SECTOR 4** |  |  | 2025-05-14 | 2025-07-26 |  |  |  |  |
| A1144 |  | Suministro y colocación de colchón caja plastificada de 5.0x2.0x0.30 m (Malla 10x12 cm. Dext=3.7mm) |  | 12d | 2025-05-14 | 2025-05-25 | A1126 SS+5d, A1123 | 60d | 0d | GAVION COLCHON PLASTIFICADO 5x2x0.3 m, abertura 10x12 cm, 3.7mm [118] |
| A1145 |  | Suministro y colocación gavión caja plastificada de 5.0x1.0x1.0 m (Malla 10x12 cm. Dext=3.7mm) |  | 62d | 2025-05-26 | 2025-07-26 | A1144 | 112d |  | GAVION TIPO CAJA DE 5.0 x 1.0 x 1.0 m, abertura 10x12cm, Dext=3,7mm (PVC) [503] |
|  | 6 | **ENCAUZAMIENTO DE RÍO - SECTOR 5** |  |  | 2025-07-24 | 2025-09-16 |  |  |  |  |
| A1340 |  | Inicio Sector 5 | milestone | 0d | 2025-07-24 | 2025-07-24 | A1137, A1330 | 0d |  |  |
| A1350 |  | Fin Sector 5 | milestone | 0d | 2025-09-16 | 2025-09-16 | A1159 FF, A1460 FF | 0d |  |  |

| ID | WBS | Activity | Type | Duration | Start | Finish | Predecessors | Total float | Free float | Resources |
| --- | --- | --- | --- | --- | --- | --- | --- | --- | --- | --- |
|  | 1 | **MOVIMIENTO DE TIERRAS PARA DIQUE LONGITUDINALES - SECTOR 5** |  |  | 2025-07-24 | 2025-09-12 |  |  |  |  |
| A1148 |  | Desbroce y remoción de suelo vegetal con equipo |  | 1d | 2025-07-24 | 2025-07-24 | A1340 SS, A1023 | 0d |  |  |
| A1149 |  | Excavación en material común |  | 6d | 2025-07-25 | 2025-07-30 | A1148 | 0d |  |  |
| A1157 |  | Proceso y selección de material propio |  | 10d | 2025-07-26 | 2025-08-04 | A1149 SS+1d, A1135 | 0d |  |  |
| A1153 |  | Relleno compactado con equipo pesado |  | 10d | 2025-07-27 | 2025-08-05 | A1157 SS+1d | 0d |  |  |
| A1155 |  | Perfilado de taludes de dique con equipo |  | 11d | 2025-07-27 | 2025-08-06 | A1153 SS | 51d |  |  |
| A1156 |  | Suministro, habilitación y colocación de geotextil no tejido 400 g/m2 |  | 9d | 2025-07-28 | 2025-08-05 | A1153 SS+1d, A1134 | 0d |  | Geotextil no tejido 400 gr/m2 [14569] |
| A1150 |  | Excavación para conformación de uña antisocavante |  | 7d | 2025-07-31 | 2025-08-06 | A1149 | 37d | 0d |  |
| A1151 |  | Colocación de protección para geotextil |  | 15d | 2025-07-31 | 2025-08-14 | A1156 SS+3d | 0d |  |  |
| A1152 |  | Conformación y compactación de superficie para fundación con equipo pesado |  | 5d | 2025-08-12 | 2025-08-16 | A1162 SS+5d | 37d |  |  |
| A1154 |  | Relleno propio sin compactar |  | 3d | 2025-09-10 | 2025-09-12 | A1153, A1131, A1073 SS | 79d | 45d |  |
|  | 2 | **ENROCADO DE PROTECCIÓN - SECTOR 5** |  |  | 2025-07-31 | 2025-09-16 |  |  |  |  |
| A1160 |  | Colocación de roca seleccionada, en uña antisocavante |  | 42d | 2025-07-31 | 2025-09-10 | A1151 SS | 0d |  | Roca [9515.71 m3] |
| A1159 |  | Colocación de roca seleccionada, en cara húmeda de talud |  | 38d | 2025-08-10 | 2025-09-16 | A1160 SS+10d | 0d |  | Roca [9791.1 m3] |
|  | 3 | **REMOCION DE ENROCADO DE DIQUES EN MAL ESTADO - SECTOR 5** |  |  | 2025-08-07 | 2025-08-20 |  |  |  |  |
| A1162 |  | Remoción de enrocado de cara húmeda de talud |  | 10d | 2025-08-07 | 2025-08-16 | A1150 | 37d | 0d |  |
| A1163 |  | Selección y acopio de roca removida |  | 4d | 2025-08-17 | 2025-08-20 | A1162, A1142 | 114d | 66d |  |
|  | 7 | **ENCAUZAMIENTO DE RÍO - SECTOR 6** |  |  | 2025-09-17 | 2025-12-08 |  |  |  |  |
| A1360 |  | Inicio Sector 6 | milestone | 0d | 2025-09-17 | 2025-09-17 | A1159, A1350 | 0d |  |  |
| A1370 |  | Fin Sector 6 | milestone | 0d | 2025-12-08 | 2025-12-08 | A1177 FF, A1480 FF | 7d |  |  |
|  | 1 | **MOVIMIENTO DE TIERRAS PARA DIQUE LONGITUDINALES - SECTOR 6** |  |  | 2025-09-17 | 2025-11-09 |  |  |  |  |
| A1166 |  | Desbroce y remoción de suelo vegetal con equipo |  | 1d | 2025-09-17 | 2025-09-17 | A1360 SS | 0d |  |  |
| A1167 |  | Excavación en material común |  | 19d | 2025-09-18 | 2025-10-06 | A1166 | 0d |  |  |
| A1175 |  | Proceso y selección de material propio |  | 32d | 2025-09-20 | 2025-10-21 | A1167 SS+2d | 25d | 1d |  |
| A1170 |  | Conformación y compactación de superficie para fundación con equipo pesado |  | 5d | 2025-09-23 | 2025-09-27 | A1167 SS+5d, A1152 | 0d |  |  |
| A1171 |  | Relleno compactado con equipo pesado |  | 32d | 2025-09-26 | 2025-10-27 | A1170 SS+3d | 0d |  |  |
| A1173 |  | Perfilado de taludes de dique con equipo |  | 8d | 2025-09-27 | 2025-10-04 | A1171 SS+1d, A1155 | 0d |  |  |
| A1169 |  | Colocación de protección para geotextil |  | 12d | 2025-09-29 | 2025-10-10 | A1174 SS | 0d |  |  |
| A1174 |  | Suministro, habilitación y colocación de geotextil no tejido 400 g/m2 |  | 7d | 2025-09-29 | 2025-10-05 | A1173 SS+2d, A1156 | 0d |  | Geotextil no tejido 400 gr/m2 [12327] |
| A1168 |  | Excavación para conformación de uña antisocavante |  | 13d | 2025-10-07 | 2025-10-19 | A1167 | 7d | 0d |  |
| A1172 |  | Relleno propio sin compactar |  | 13d | 2025-10-28 | 2025-11-09 | A1171, A1154 | 34d | 0d |  |

| ID | WBS | Activity | Type | Duration | Start | Finish | Predecessors | Total float | Free float | Resources |
| --- | --- | --- | --- | --- | --- | --- | --- | --- | --- | --- |
|  | 2 | **ENROCADO DE PROTECCIÓN - SECTOR 6** |  |  | 2025-09-30 | 2025-12-08 |  |  |  |  |
| A1178 |  | Colocación de roca seleccionada, en uña antisocavante |  | 41d | 2025-09-30 | 2025-11-09 | A1169 SS+1d | 0d |  | Roca [9296.4 m3] |
| A1177 |  | Colocación de roca seleccionada, en cara húmeda de talud |  | 29d | 2025-11-10 | 2025-12-08 | A1178 | 0d |  | Roca [7768.62 m3] |
|  | 5 | **GAVIONES - SECTOR 6** |  |  | 2025-11-16 | 2025-11-30 |  |  |  |  |
| A1180 |  | Suministro y colocación gavión caja plastificada de 5.0x1.0x1.0 m (Malla 10x12 cm. Dext=3.7mm) |  | 15d | 2025-11-16 | 2025-11-30 | A1178 FS+6d, A1145 | 0d |  | GAVION TIPO CAJA DE 5.0 x 1.0 x 1.0 m, abertura 10x12cm, Dext=3,7mm (PVC) [60] |
|  | 8 | **ENCAUZAMIENTO DE RÍO - SECTOR 7** |  |  | 2025-10-20 | 2025-12-08 |  |  |  |  |
| A1380 |  | Inicio Sector 7 | milestone | 0d | 2025-10-20 | 2025-10-20 | A1168 | 7d | 0d |  |
| A1390 |  | Fin Sector 7 | milestone | 0d | 2025-12-08 | 2025-12-08 | A1195 FF, A1200 FF, A1230 FF, A1189 FF, A1203 FF | 7d |  |  |
|  | 1 | **MOVIMIENTO DE TIERRAS PARA DIQUE LONGITUDINALES - SECTOR 7** |  |  | 2025-10-20 | 2025-11-16 |  |  |  |  |
| A1183 |  | Desbroce y remoción de suelo vegetal con equipo |  | 1d | 2025-10-20 | 2025-10-20 | A1380 SS | 24d | 0d |  |
| A1184 |  | Excavación en material común |  | 6d | 2025-10-21 | 2025-10-26 | A1183 | 24d | 0d |  |
| A1193 |  | Proceso y selección de material propio |  | 10d | 2025-10-23 | 2025-11-01 | A1184 SS+2d, A1175 | 24d | 0d |  |
| A1188 |  | Relleno compactado con equipo pesado |  | 14d | 2025-10-25 | 2025-11-07 | A1193 SS+2d | 24d | 0d |  |
| A1190 |  | Perfilado de taludes de dique con equipo |  | 4d | 2025-10-26 | 2025-10-29 | A1188 SS+1d | 24d | 0d |  |
| A1185 |  | Excavación para conformación de uña antisocavante |  | 3d | 2025-10-27 | 2025-10-29 | A1184 | 42d | 0d |  |
| A1191 |  | Suministro, habilitación y colocación de geotextil no tejido 400 g/m2 |  | 3d | 2025-10-27 | 2025-10-29 | A1190 SS+1d | 24d | 0d | Geotextil no tejido 400 gr/m2 [8003]; Geotextil no tejido 200 gr/m2 [298] |
| A1186 |  | Colocación de protección para geotextil |  | 5d | 2025-10-30 | 2025-11-03 | A1191 | 24d | 0d |  |
| A1187 |  | Conformación y compactación de superficie para fundación con equipo pesado |  | 3d | 2025-10-30 | 2025-11-01 | A1185 | 42d | 8d |  |
| A1189 |  | Relleno propio sin compactar |  | 2d | 2025-11-10 | 2025-11-11 | A1188, A1172, A1187 | 34d | 27d |  |
| A1192 |  | Suministro, habilitación y colocación de geotextil no tejido 200 g/m2 |  | 1d | 2025-11-16 | 2025-11-16 | A1202 SS | 0d |  |  |
|  | 2 | **ENROCADO DE PROTECCIÓN - SECTOR 7** |  |  | 2025-10-30 | 2025-11-14 |  |  |  |  |
| A1196 |  | Colocación de roca seleccionada, en uña antisocavante |  | 11d | 2025-10-30 | 2025-11-09 | A1186 SS | 24d | 0d | Roca [2969.99 m3] |
| A1195 |  | Colocación de roca seleccionada, en cara húmeda de talud |  | 11d | 2025-11-04 | 2025-11-14 | A1196 SS+5d | 24d |  | Roca [2624.72 m3] |
|  | 3 | **REMOCION DE ENROCADO DE DIQUES EN MAL ESTADO - SECTOR 7** |  |  | 2025-10-20 | 2025-10-28 |  |  |  |  |
| A1198 |  | Remoción de enrocado de cara húmeda de talud |  | 5d | 2025-10-20 | 2025-10-24 | A1167 FS+13d | 48d | 0d |  |
| A1199 |  | Remoción de enrocado de uña |  | 1d | 2025-10-25 | 2025-10-25 | A1198 | 48d | 0d |  |
| A1200 |  | Selección y acopio de roca removida |  | 3d | 2025-10-26 | 2025-10-28 | A1198, A1199, A1163 | 48d | 41d |  |

| ID | WBS | Activity | Duration | Start | Finish | Predecessors | Total float | Free float | Resources |
| --- | --- | --- | --- | --- | --- | --- | --- | --- | --- |
|  | 5 | **GAVIONES - SECTOR 7** |  | 2025-11-16 | 2025-12-08 |  |  |  |  |
| A1202 |  | Suministro y colocación de colchón caja plastificada de 5.0x2.0x0.30 m (Malla 10x12 cm. Dext=3.7mm) | 4d | 2025-11-16 | 2025-11-19 | A1183, A1180 SS | 0d |  | GAVION COLCHON PLASTIFICADO 5x2x0.3 m, abertura 10x12 cm, 3.7mm [16] |
| A1203 |  | Suministro y colocación gavión caja plastificada de 5.0x1.0x1.0 m (Malla 10x12 cm. Dext=3.7mm) | 23d | 2025-11-16 | 2025-12-08 | A1192 SS | 0d |  | GAVION TIPO CAJA DE 5.0 x 1.0 x 1.0 m, abertura 10x12cm, Dext=3,7mm (PVC) [69] |
|  | 10 | **ESTRUCTURA DE CAPTACIÓN LATERAL** |  | 2024-09-07 | 2025-12-08 |  |  |  |  |
| A1240 |  | Sector 1 - Toma DIPRO-017-MD | 230d | 2024-09-07 | 2025-04-24 | A1280 SS+50d | 235d | 6d | Acero Corrugado fy = 4200 kg/cm2 grado 60 [9227.17]; arena gruesa [2410]; Cemento Portlamd Tipo I (42.5 kg) [1]; Concreto premezclado F'C=280 kg/cm2 [123]; Concreto premezclado F'C=175 kg/cm2 [147]; Geotextil no tejido 400 gr/m2 [821]; REJILLA METALICA 2.20x1.50m [1]; Concreto premezclado F'C=100 kg/cm2 [30]; Roca con mortero [357 m3]; Mamposteria piedra [191 m3] |
| A1470 |  | Sector 2 - Toma DIPRO-016-MD // DIPRO-014-MD // DIPRO-018-MD | 250d | 2025-03-06 | 2025-11-10 | A1260 SS+30d | 35d |  | Acero Corrugado fy = 4200 kg/cm2 grado 60 [27687.5]; arena gruesa [2800]; Cemento Portlamd Tipo I (42.5 kg) [1]; Concreto premezclado F'C=280 kg/cm2 [569]; Concreto premezclado F'C=175 kg/cm2 [354]; Geotextil no tejido 400 gr/m2 [2465]; REJILLA METALICA 2.20x1.50m [4]; Concreto premezclado F'C=100 kg/cm2 [30]; Roca con mortero [357 m3]; Mamposteria piedra [191 m3] |
| A1480 |  | Sector 6 - Toma DIPRO-012-MI | 80d | 2025-09-17 | 2025-12-05 | A1360 SS | 10d | 3d | Acero Corrugado fy = 4200 kg/cm2 grado 60 [9229.17]; arena gruesa [730]; Cemento Portlamd Tipo I (42.5 kg) [1]; Concreto premezclado F'C=280 kg/cm2 [123]; Concreto premezclado F'C=175 kg/cm2 [157]; Geotextil no tejido 400 gr/m2 [821]; REJILLA METALICA 2.20x1.50m [1]; Concreto premezclado F'C=100 kg/cm2 [30]; Roca con mortero [75 m3] |
| A1230 |  | Sector 7 - Toma DIPRO-013-MD | 50d | 2025-10-20 | 2025-12-08 | A1380 SS | 7d | 0d | Acero Corrugado fy = 4200 kg/cm2 grado 60 [9229.17]; arena gruesa [560]; Cemento Portlamd Tipo I (42.5 kg) [1]; Concreto premezclado F'C=280 kg/cm2 [123]; Concreto premezclado F'C=175 kg/cm2 [157]; Geotextil no tejido 400 gr/m2 [821]; REJILLA METALICA 2.20x1.50m [1]; Concreto premezclado F'C=100 kg/cm2 [30] |
|  | 11 | **RAMPAS Y ACCESOS A CORONA** |  | 2024-09-02 | 2025-11-10 |  |  |  |  |
| A1420 |  | Sector 1 - Rampa Simple y Acceso Corona | 241d | 2024-09-02 | 2025-04-30 | A1280 SS+45d | 229d | 0d | Geotextil no tejido 400 gr/m2 [4878] |
| A1440 |  | Sector 3 - Acceso Corona | 105d | 2025-01-20 | 2025-05-04 | A1300 SS+35d | 4d |  | Geotextil no tejido 400 gr/m2 [1951] |
| A1430 |  | Sector 2 - Rampa Simple y Acceso Corona | 250d | 2025-03-06 | 2025-11-10 | A1260 SS+30d | 35d |  | Geotextil no tejido 400 gr/m2 [6829] |
| A1450 |  | Sector 4 - Rampa Simple y Acceso Corona | 50d | 2025-05-29 | 2025-07-17 | A1320 SS+20d, A1111, A1118, A1113, A1117 | 6d |  | Geotextil no tejido 400 gr/m2 [1591] |
| A1460 |  | Sector 5 - Acceso Corona | 35d | 2025-08-08 | 2025-09-11 | A1340 SS+15d, A1116 | 5d |  | Geotextil no tejido 400 gr/m2 [975] |
|  | 1 | **ALCANTARILLA DE RETORNO** |  | 2024-09-05 | 2025-07-13 |  |  |  |  |
| A1400 |  | Sector 1 - Alcantarilla de Retorno DIPRO-018-MD // DIPRO-012-MI | 235d | 2024-09-05 | 2025-04-27 | A1280 SS+48d | 232d | 3d | Acero Corrugado fy = 4200 kg/cm2 grado 60 [8030.87]; arena gruesa [29.12]; Cemento Portlamd Tipo I (42.5 kg) [3]; Concreto premezclado F'C=280 kg/cm2 [94]; Concreto premezclado F'C=100 kg/cm2 [12]; Concreto premezclado F'C=175 kg/cm2 [220]; Geotextil no tejido 400 gr/m2 [2056]; REJILLA METALICA 2.20x1.50m [2]; Mamposteria piedra [148 m3] |
| A1490 |  | Sector 3 - Alcantarilla de Retorno DIPRO-012-MI // DIPRO-011-MI | 100d | 2025-01-20 | 2025-04-29 | A1300 SS+35d | 9d |  | Acero Corrugado fy = 4200 kg/cm2 grado 60 [8030.87]; arena gruesa [29.12]; Concreto premezclado F'C=100 kg/cm2 [12]; Concreto premezclado F'C=175 kg/cm2 [98]; Geotextil no tejido 400 gr/m2 [2056]; REJILLA METALICA 2.20x1.50m [2]; Concreto premezclado F'C=280 kg/cm2 [94] |
| A1500 |  | Sector 4 - Alcantarilla de Retorno DIPRO-010-MI | 61d | 2025-05-14 | 2025-07-13 | A1320 SS+5d | 10d |  | Acero Corrugado fy = 4200 kg/cm2 grado 60 [4015.43]; arena gruesa [29.12]; Concreto premezclado F'C=100 kg/cm2 [12]; Concreto premezclado F'C=175 kg/cm2 [50]; Geotextil no tejido 400 gr/m2 [1028]; REJILLA METALICA 2.20x1.50m [1]; Concreto premezclado F'C=280 kg/cm2 [94] |
|  | 2 | **ARQUITECTURA Y PAISAJISMO** |  | 2024-12-16 | 2025-09-06 |  |  |  |  |
| A1410 |  | Arquitectura y Paisajismo | 265d | 2024-12-16 | 2025-09-06 | A1280 SS+150d | 100d |  | Acero Corrugado fy = 4200 kg/cm2 grado 60 [6750.32]; Cemento Portlamd Tipo I (42.5 kg) [1889]; Concreto premezclado F'C=280 kg/cm2 [132] |
|  | 12 | **PRUEBAS DE CONTROL DE CALIDAD** |  | 2024-07-04 | 2025-12-08 |  |  |  |  |
| A1250 |  | Pruebas de Control de Calidad | 523d | 2024-07-04 | 2025-12-08 | A1017 SS | 7d |  |  |
